# New Product Development - Schedule 1

Schedule from MS Project, 2020-04-15 to 2021-01-06, status date 2019-08-02, costs in $.
The "...Sample schedule with Instructors artifacts" is a transport schedule, meaning it is intended to enable transfer of artifacts to a user's schedule or Global.mpt. This schedule is for educational purposes only. It is provided as-is. The author acepts no liablity for the consequences of using this schedule or its artifacts. No support is offered. The artifacts include views to assist in setting up an improving estimating data in a schedule template using actual data from specific schedules made from that template. Additionally, there are views that facilitate making a status report from that specific schedule. Any questions, email ogilders@sbcglobal.net. Oliver Gildersleeve, Jr. June 26, 2018.

## Calendars

- Standard: Mon-Fri 08:00-12:00, 13:00-17:00; Sat-Sun off.

## Resources

| Resource | Group | Rate |
| --- | --- | --- |
| Engineer | Engineering | 100 |
| PM | PMO | 100 |
| Manager | Management | 100 |
| Marketing | Marketing | 100 |
| BA | Engineering | 100 |
| Tester | QA | 100 |
| Operations | Operations | 100 |
| Support | Support | 100 |
| Customer | Customer | 100 |
| Components |  | 10 |
| Team |  |  |
| Resource |  | 100 |

## Schedule

| ID | WBS | Task | Type | Duration | Start | Finish | Predecessors | Baseline start | Baseline finish | Baseline duration | Total slack | Free slack | Resources | Work | Cost | Baseline cost | T21 Work Number | Text19 | T15 Factor | Text27 | Text29 | Text13 |
| --- | --- | --- | --- | --- | --- | --- | --- | --- | --- | --- | --- | --- | --- | --- | --- | --- | --- | --- | --- | --- | --- | --- |
| 1 | 1 | **New Product - Parametric Plan** |  | 155.67d | 2020-04-15 | 2020-11-18 |  | 2020-04-15 | 2020-12-02 | 165.21d | -12.54d | 0d |  | 1814.75h | 100,475 | 112,975 | 1,522 |  |  |  |  |  |
| 2 | 1.1 | Project started | milestone | 0d | 2020-04-15 | 2020-04-15 |  | 2020-04-15 | 2020-04-15 | 0d | -12.54d | 0d |  |  |  |  |  |  |  |  |  |  |
| 3 | 1.2 | **Initiating** |  | 19.67d | 2020-04-15 | 2020-05-12 |  | 2020-04-15 | 2020-05-12 | 19.67d | -12.54d | 0d |  | 142h | 14,200 | 14,200 | 134 | 2729.87 |  |  |  |  |
| 4 | 1.2.1 | **Bidding external project (else, Inactivate)** |  | 19d | 2020-04-15 | 2020-05-11 |  | 2020-04-15 | 2020-05-11 | 19d | -11.88d | 0d |  | 54h | 5,400 | 5,400 | 54 | 26.5 |  |  |  |  |
| 5 | 1.2.1.1 | Specifications: review & produce draft, send to peer review |  | 3.33d | 2020-04-15 | 2020-04-20 | 2 | 2020-04-15 | 2020-04-20 | 3.33d | -11.88d | 0d | Engineer [75%] | 20h | 2,000 | 2,000 | 20 | 3.5 | Specs | -4294924528.67 | 0.67 |  |
| 6 | 1.2.1.2 | Schedule & cost: specific copy template, scaled. Add mitigations, special documents, constraints. |  | 1d | 2020-04-20 | 2020-04-21 | 5 | 2020-04-20 | 2020-04-21 | 1d | -11.88d | 0d | PM [75%] | 6h | 600 | 600 |  |  | Fixed | -4294924528.46 | 0.33 |  |
| 7 | 1.2.1.3 | Bid: prepare & submit |  | 2.67d | 2020-04-21 | 2020-04-23 | 6 | 2020-04-21 | 2020-04-23 | 2.67d | -11.88d | 0d | Manager [75%] | 16h | 1,600 | 1,600 | 16 |  | Fixed | -4294924528.38 | 0.33 |  |
| 8 | 1.2.1.4 | Awarded: Statement of Work: negotiate, contract |  | 2d | 2020-05-08 | 2020-05-11 | 7FS+10d | 2020-05-08 | 2020-05-11 | 2d | -11.88d | 0d | Manager [75%] | 12h | 1,200 | 1,200 | 12 | 12 | Fixed | -4294924513.67 | 1.33 |  |
| 9 | 1.2.1.5 | Contract signed | milestone | 0d | 2020-05-11 | 2020-05-11 | 8 | 2020-05-11 | 2020-05-11 | 0d | -11.88d | 0d |  |  |  |  |  |  | Fixed | -4294924512.67 |  |  |
| 10 | 1.2.2 | **Initating internal project (else, Inactivate)** |  | 19.67d | 2020-04-15 | 2020-05-12 |  | 2020-04-15 | 2020-05-12 | 19.67d | -12.54d | 0d |  | 88h | 8,800 | 8,800 | 80 | 129.64 |  |  |  |  |
| 11 | 1.2.2.1 | White paper: produce, focus group, review |  | 0.33d | 2020-04-15 | 2020-04-15 | 2 | 2020-04-15 | 2020-04-15 | 0.33d | -12.54d | 0d | Engineer [75%] | 2h | 200 | 200 |  | 8.4 | Pages | -4294924535.67 | 0.67 |  |
| 12 | 1.2.2.2 | Survey report: conduct, analyze, draft |  | 0.67d | 2020-04-15 | 2020-04-15 | 11 | 2020-04-15 | 2020-04-15 | 0.67d | -12.54d | 0d | Marketing [75%] | 4h | 400 | 400 | 12 | 16.8 | Pages | -4294924520.67 | 0.67 |  |
| 13 | 1.2.2.3 | Market research benefit report: perform, review |  | 0.83d | 2020-04-23 | 2020-04-23 | 12FS+5d | 2020-04-23 | 2020-04-23 | 0.83d | -12.54d | 0d | Marketing [75%] | 5h | 500 | 500 | 12 | 14.59 | Pages | -4294924519.67 | 0.67 |  |
| 14 | 1.2.2.4 | Charter of Specific project: draft, review, get approval |  | 0.33d | 2020-04-23 | 2020-04-24 | 13 | 2020-04-23 | 2020-04-24 | 0.33d | -12.54d | 0d | PM [75%] | 2h | 200 | 200 |  | 8.4 | Pages | -4294924518.67 | 0.67 |  |
| 15 | 1.2.2.5 | Customers needs (problem, objectives): draft, peer reivew, revise |  | 7.5d | 2020-04-24 | 2020-05-05 | 14 | 2020-04-24 | 2020-05-05 | 7.5d | -12.54d | 0d | BA [75%] | 45h | 4,500 | 4,500 | 30 | 45.78 | Requirements | -4294924518.46 | 0.67 | 0.4 |
| 16 | 1.2.2.6 | Specifications document: draft, review, get approval |  | 5d | 2020-05-05 | 2020-05-12 | 15 | 2020-05-05 | 2020-05-12 | 5d | -12.54d | 0d | Engineer [75%] | 30h | 3,000 | 3,000 | 20 | 73.25 | Requirements | -4294924515.67 |  | 0.6 |
| 17 | 1.2.2.7 | New idea documented | milestone | 0d | 2020-05-12 | 2020-05-12 | 16 | 2020-05-12 | 2020-05-12 | 0d | -12.54d | 0d |  |  |  |  |  |  | Fixed |  |  |  |
| 18 | 1.3 | **Designing** |  | 44.58d | 2020-05-12 | 2020-07-14 |  | 2020-05-12 | 2020-07-14 | 44.58d | -12.54d | 0d |  | 727.5h | 72,750 | 72,750 | 385 | 567.11 |  |  |  |  |
| 19 | 1.3.1 | Acceptance test plan: draft, peer review |  | 3.75d | 2020-05-12 | 2020-05-18 | 9, 17 | 2020-05-12 | 2020-05-18 | 3.75d | -12.54d | 0d | Tester [75%] | 22.5h | 2,250 | 2,250 | 15 | 45.78 | Requirements | -4294924507.67 | 0.67 | 0.4 |
| 20 | 1.3.2 | General design document: draft, peer review, revise |  | 2.5d | 2020-05-18 | 2020-05-20 | 19 | 2020-05-18 | 2020-05-20 | 2.5d | -12.54d | 0d | Engineer [75%] | 15h | 1,500 | 1,500 | 10 | 45.78 | Requirements | -4294924505.67 | 0.67 | 0.4 |
| 21 | 1.3.3 | Prototypes - initial: develop, developer test, peer inspection |  | 33.33d | 2020-05-20 | 2020-07-07 | 20 | 2020-05-20 | 2020-07-07 | 33.33d | -12.54d | 0d | Engineer [225%] | 600h | 60,000 | 60,000 | 300 | 576 | Features | -4294924504.67 | 1.33 | 2.67 |
| 22 | 1.3.4 | Prototypes - final: develop, developer test, peer inspection |  | 5d | 2020-07-07 | 2020-07-14 | 21 | 2020-07-07 | 2020-07-14 | 5d | -12.54d | 0d | Engineer [225%] | 90h | 9,000 | 9,000 | 60 | 137.33 | Requirements | -4294924501.67 | 0.67 | 0.4 |
| 23 | 1.3.5 | Prototype designed | milestone | 0d | 2020-07-14 | 2020-07-14 | 22 | 2020-07-14 | 2020-07-14 | 0d | -12.54d | 0d |  |  |  |  |  |  | Fixed |  |  |  |
| 24 | 1.4 | **Developing** |  | 45.67d | 2020-07-14 | 2020-09-15 |  | 2020-07-14 | 2020-09-15 | 45.67d | -12.54d | 0d |  | 814h | 400 | 400 | 820 | 270.85 |  |  |  |  |
| 25 | 1.4.1 | Sprint 1 |  | 15d | 2020-07-14 | 2020-08-04 | 23 | 2020-07-14 | 2020-08-04 | 15d | -12.54d | 0d | Team [225%] | 270h |  |  | 270 | 270 | Sprints |  |  |  |
| 26 | 1.4.2 | Sprint 2 |  | 15d | 2020-08-04 | 2020-08-25 | 25 | 2020-08-04 | 2020-08-25 | 15d | -12.54d | 0d | Team [225%] | 270h |  |  | 270 |  | Sprints |  |  |  |
| 27 | 1.4.3 | Sprint 3 |  | 15d | 2020-08-25 | 2020-09-15 | 26 | 2020-08-25 | 2020-09-15 | 15d | -12.54d | 0d | Team [225%] | 270h |  |  | 270 |  | Sprints |  |  |  |

Notes:
- 8: Charter content / o Project type: define / - Bid & contract / - New idea / o Scope: what's in, what's out / o Schedule template: existing, derivative, new / o Budget / o Risk events: check the check list, add more / o Key personnel / o Deadlines & constraints / o Priority method; initial priority
- 25: Notes: good for explanations, e.g. in a sprint: / Backlog: select features for sprint / Components: design / Test rig report: develop rig, peer inspect, document / Components: build, developer test, regression test / Sprint's components: deliver. Backlog: select next features / These activities are performed but not scheduled day-by-day
- 27: Add more sprints, if needed

| ID | WBS | Task | Type | Duration | Start | Finish | Predecessors | Baseline start | Baseline finish | Baseline duration | Total slack | Free slack | Constraint | Deadline | Resources | Work | Cost | Baseline cost | T15 Factor | Text27 | T21 Work Number | T26 Next 14 calendar days | Text19 | Text29 | Text13 |
| --- | --- | --- | --- | --- | --- | --- | --- | --- | --- | --- | --- | --- | --- | --- | --- | --- | --- | --- | --- | --- | --- | --- | --- | --- | --- |
| 28 | 1.4.4 | **Additional sprints: Adapt schedule** |  | 0d | 2020-08-25 | 2020-08-25 |  | 2020-08-25 | 2020-08-25 | 0d | 96.75d |  |  |  |  |  |  |  | Sprints | -4294924494.67 |  |  |  |  |  |
| 29 | 1.4.4.1 | Additional sprints: performing | milestone | 0d | 2020-08-25 | 2020-08-25 | 26 | 2020-08-25 | 2020-08-25 | 0d | 96.75d |  |  |  |  |  |  |  | Fixed |  |  |  |  |  |  |
| 30 | 1.4.5 | **QA & integration testing** |  | 0.67d | 2020-09-15 | 2020-09-15 |  | 2020-09-15 | 2020-09-15 | 0.67d | -12.54d | 0d |  |  |  | 4h | 400 | 400 |  |  | 10 | +14 |  |  |  |
| 31 | 1.4.5.1 | QA report of selected components: Perform QA & integration test. |  | 0.67d | 2020-09-15 | 2020-09-15 | 27 | 2020-09-15 | 2020-09-15 | 0.67d | -12.54d | 0d |  |  | Tester [75%] | 4h | 400 | 400 | Pages | -4294924497.67 | 10 |  | 1.19 | 0.67 |  |
| 32 | 1.5 | **Assembling & life testing** |  | 1d | 2020-09-15 | 2020-09-16 |  | 2020-09-15 | 2020-09-16 | 1d | -12.54d | 0d |  |  |  | 6h | 600 | 600 |  |  |  |  | 27 |  |  |
| 33 | 1.5.1 | Assembly report: draft, review, revise |  | 0.5d | 2020-09-15 | 2020-09-16 | 31 | 2020-09-15 | 2020-09-16 | 0.5d | -12.54d | 0d |  |  | Engineer [75%] | 3h | 300 | 300 | Pages | -4294924494.67 | 4.5 |  | 12.6 | 0.67 |  |
| 34 | 1.5.2 | Life test report: test, draft, review, revise |  | 0.5d | 2020-09-16 | 2020-09-16 | 33 | 2020-09-16 | 2020-09-16 | 0.5d | -12.54d | 0d |  |  | Tester [75%] | 3h | 300 | 300 | Pages | -4294924493.67 | 4.5 |  | 12.6 | 0.67 |  |
| 35 | 1.5.3 | Life test: successfully completed | milestone | 0d | 2020-09-16 | 2020-09-16 | 34 | 2020-09-16 | 2020-09-16 | 0d | -12.54d | 0d |  |  | Tester [75%] |  |  |  | Fixed | -4294924493.29 |  |  |  |  |  |
| 36 | 1.6 | **Setting up production** |  | 17.62d | 2020-09-16 | 2020-10-12 |  | 2020-09-16 | 2020-10-12 | 17.62d | -12.54d | 0d |  |  |  | 75.75h | 7,575 | 7,575 |  |  | 114 |  | 115.82 |  |  |
| 37 | 1.6.1 | Production process document: design, peer review, revise, get approval |  | 1.25d | 2020-09-16 | 2020-09-18 | 35 | 2020-09-16 | 2020-09-18 | 1.25d | -12.54d | 0d |  |  | Operations [75%] | 7.5h | 750 | 750 | Pages | -4294924491.67 | 12 |  | 9.97 | 1.33 |  |
| 38 | 1.6.2 | Order parts for production facility & initial product parts inventory |  | 1.33d | 2020-09-18 | 2020-09-21 | 37 | 2020-09-18 | 2020-09-21 | 1.33d | -12.54d | 0d |  |  | Operations [75%] | 8h | 800 | 800 | Parts |  |  |  | 30.35 |  |  |
| 39 | 1.6.3 | Receive parts, build production line |  | 5.33d | 2020-09-28 | 2020-10-05 | 38FS+5d | 2020-09-28 | 2020-10-05 | 5.33d | -12.54d | 0d |  |  | Operations [75%] | 32h | 3,200 | 3,200 | Parts |  | 24 |  | 60.67 |  |  |
| 40 | 1.6.4 | Production line: initial run. Make adjustments. |  | 0.67d | 2020-10-05 | 2020-10-06 | 39 | 2020-10-05 | 2020-10-06 | 0.67d | -12.54d | 0d |  |  | Operations [75%] | 4h | 400 | 400 | Analogous | -4294924490.67 |  |  | 38.4 |  | 24 |
| 41 | 1.6.5 | Initial production: make, test |  | 0.04d | 2020-10-06 | 2020-10-06 | 40 | 2020-10-06 | 2020-10-06 | 0.04d | -12.54d | 0d |  |  | Operations [75%] | 0.25h | 25 | 25 | Products | -4294924487.67 | 60 |  | 9.6 | 0.67 |  |
| 42 | 1.6.6 | Operations initial problems: resolve |  | 4d | 2020-10-06 | 2020-10-12 | 41 | 2020-10-06 | 2020-10-12 | 4d | -12.54d | 0d |  |  | Engineer [75%] | 24h | 2,400 | 2,400 | Analogous | -4294924492.67 |  |  | 4.27 | 2.67 | 16 |
| 43 | 1.7 | **Market planning** |  | 0.33d | 2020-05-12 | 2020-05-12 |  | 2020-05-12 | 2020-05-12 | 0.33d | 94.75d |  |  |  |  | 2h | 200 | 200 |  |  | 10 |  | 56.94 |  |  |
| 44 | 1.7.1 | Initial marketing strategy document: produce, peer review, revise |  | 0.33d | 2020-05-12 | 2020-05-12 | 9, 15, 17 | 2020-05-12 | 2020-05-12 | 0.33d | 94.75d | 0d |  |  | Marketing [75%] | 2h | 200 | 200 | Pages |  |  |  |  |  |  |
| 45 | 1.7.2 | Initial marketing plan document: produce, peer review, revise | milestone | 0d | 2020-05-12 | 2020-05-12 | 44 | 2020-05-12 | 2020-05-12 | 0d | 94.75d |  |  |  | Marketing [75%] |  |  |  | Pages |  |  |  |  |  |  |
| 46 | 1.8 | **Marketing materials** |  | 5.25d | 2020-10-05 | 2020-10-12 |  | 2020-10-05 | 2020-10-12 | 5.25d | -12.54d | 0d |  |  |  | 7.5h | 750 | 1,250 |  |  | 10 |  |  |  |  |
| 47 | 1.8.1 | Marketing materials (brochures, ads, commercials): prototype, review, revise, produce | milestone | 0d | 2020-10-06 | 2020-10-06 | 41FF, 45 | 2020-10-05 | 2020-10-06 | 0.83d | -8.54d | 0d |  |  | Marketing [75%] |  |  | 500 | Pages |  |  |  |  |  |  |
| 48 | 1.8.2 | Help desk materials (troubleshooting tree, training): produce, qualify |  | 1.25d | 2020-10-05 | 2020-10-06 | 41FF, 45 | 2020-10-05 | 2020-10-06 | 1.25d | -8.54d | 0d |  |  | Support [75%] | 7.5h | 750 | 750 | Requirements | -4294924505.67 |  |  | 68.67 | 2.67 | 1.6 |
| 49 | 1.8.3 | Marketing, operations, help: readied | milestone | 0d | 2020-10-12 | 2020-10-12 | 48, 42, 47 | 2020-10-12 | 2020-10-12 | 0d | -12.54d | 0d |  |  | Marketing [75%] |  |  |  |  |  |  |  |  |  |  |
| 50 | 1.9 | **Producing** |  | 20.46d | 2020-10-12 | 2020-11-10 |  | 2020-10-26 | 2020-10-26 | 0d | -12.54d | 0d |  |  |  |  |  |  |  |  |  | +14 |  |  |  |
| 51 | 1.9.1 | Deadline | milestone | 0d | 2020-10-12 | 2020-10-12 | 49 |  |  |  | -12.54d | 0d |  | 2020-09-23 |  |  |  |  |  |  |  |  |  |  |  |
| 52 | 1.9.2 | Risk Reserve | milestone | 0d | 2020-10-26 | 2020-10-26 | 51FS+2w | 2020-10-26 | 2020-10-26 | 0d | 45.79d | 10.46d |  |  |  |  |  |  | Shock Absorber |  |  |  |  |  |  |
| 53 | 1.9.3 | Estimating Uncertainty Buffer | milestone | 0d | 2020-11-10 | 2020-11-10 | 52 | 2020-10-26 | 2020-10-26 | 0d | 35.33d | 0d | start no earlier than 2020-11-10 |  |  |  |  |  | Shock Absorber |  |  |  |  |  |  |
| 54 | 1.9.4 | Production started | milestone | 0d | 2020-11-10 | 2020-11-10 | 53 | 2020-10-26 | 2020-10-26 | 0d | 35.33d | 0d |  |  |  |  |  |  | Fixed |  |  |  |  |  |  |
| 55 | 1.9.5 | Sales & help desk: underway | milestone | 0d | 2020-11-10 | 2020-11-10 | 53, 48 | 2020-10-26 | 2020-10-26 | 0d | 35.33d | 0d |  |  |  |  |  |  | Fixed | -4294924505.29 |  |  |  |  |  |

Notes:
- 53: Add an Estimating Uncertainty Buffer: / Use a constraint (Start No Earlier Than) before start of deployment or production. / Set the constraint half the difference between the start of deployment with convervative estimates and the start of deployment using median estimates. / This buffer increases the likelihood that the resulting commitment to deploy will be achieved, even if more than half the tasks exceed their median estimates.

| ID | WBS | Task | Type | Duration | Start | Finish | Predecessors | Baseline start | Baseline finish | Baseline duration | Total slack | Free slack | Resources | Work | Cost | Baseline cost | Text19 | T21 Work Number | T15 Factor | Text27 | Text29 |
| --- | --- | --- | --- | --- | --- | --- | --- | --- | --- | --- | --- | --- | --- | --- | --- | --- | --- | --- | --- | --- | --- |
| 56 | 1.10 | **Closing** |  | 6.67d | 2020-11-10 | 2020-11-18 |  | 2020-10-26 | 2020-12-02 | 26.67d | 35.33d |  |  | 40h | 4,000 | 16,000 | 1536 | 40 |  |  |  |
| 57 | 1.10.1 | Project documents: inventoried, archivied |  | 6.67d | 2020-11-10 | 2020-11-18 | 55, 54 | 2020-10-26 | 2020-12-02 | 26.67d | 35.33d |  | PM [75%] | 40h | 4,000 | 16,000 | 1536 | 40 | Fixed | -4294924491.67 | 0.17 |
| 61 | 2 | **New Product - Analogous Plan** |  | 191d | 2020-04-15 | 2021-01-06 |  | 2020-04-15 | 2020-12-02 | 165.22d |  |  |  | 2346.75h | 234,675 |  |  | 1,939.75 |  |  |  |
| 62 | 2.1 | 0 | milestone | 0d | 2020-04-15 | 2020-04-15 |  | 2020-04-15 | 2020-04-15 | 0d | 191d |  |  |  |  |  |  |  |  |  |  |
| 63 | 2.2 | Initiating |  | 19.67d | 2020-04-15 | 2020-05-12 |  | 2020-04-15 | 2020-05-12 | 19.67d | 2.94d | 0d | Resource [90.2%] | 142h | 14,200 |  |  | 142 |  |  |  |
| 64 | 2.3 | Designing |  | 44.58d | 2020-05-12 | 2020-07-14 | 63 | 2020-05-12 | 2020-07-14 | 44.58d | 2.94d | 0d | Resource [204%] | 727.5h | 72,750 |  |  | 727.5 |  |  |  |
| 65 | 2.4 | Developing |  | 68.5d | 2020-07-14 | 2020-10-16 | 64 | 2020-07-14 | 2020-09-15 | 45.67d | 2.94d | 0d | Resource [222.8%] | 1221h | 122,100 |  |  | 814 |  |  |  |
| 66 | 2.5 | Assembling & life testing |  | 1d | 2020-10-16 | 2020-10-19 | 65 | 2020-09-15 | 2020-09-16 | 1d | 2.94d | 0d | Resource [75%] | 6h | 600 |  |  |  |  |  |  |
| 67 | 2.6 | Setting up production |  | 17.63d | 2020-10-19 | 2020-11-12 | 66 | 2020-09-16 | 2020-10-12 | 17.63d | 2.94d | 0d | Resource [53.7%] | 75.75h | 7,575 |  |  | 75.75 |  |  |  |
| 68 | 2.7 | Market planning |  | 0.33d | 2020-05-12 | 2020-05-12 | 63FF | 2020-05-12 | 2020-05-12 | 0.33d | 144.66d | 141.72d | Resource [75.8%] | 2h | 200 |  |  |  |  |  |  |
| 69 | 2.8 | Marketing materials |  | 5.25d | 2020-11-05 | 2020-11-12 | 67FF | 2020-10-05 | 2020-10-12 | 5.25d | 12.95d | 10d | Resource [29.8%] | 12.5h | 1,250 |  |  | 12.5 |  |  |  |
| 70 | 2.9 | Producing | milestone | 0d | 2020-11-26 | 2020-11-26 | 67FF+2w | 2020-10-26 | 2020-10-26 | 0d | 2.94d | 0d | Resource |  |  |  |  |  |  |  |  |
| 71 | 2.10 | Closing |  | 26.67d | 2020-11-26 | 2021-01-04 | 70, 68, 69 | 2020-10-26 | 2020-12-02 | 26.67d | 2.94d |  | Resource [75%] | 160h | 16,000 |  |  | 160 |  |  |  |
